# 机考数据中心开发计划

Schedule from MS Project, 2017-11-27 to 2017-12-14.

## Calendars

- 标准: Mon-Fri 08:00-12:00, 13:00-17:00; Sat-Sun off.

## Resources

| Resource |
| --- |
| 田军 |
| 高兴 |

## Schedule

| ID | WBS | Task | Type | Duration | Start | Finish | Predecessors | Total slack | Free slack | Constraint | Resources | Work |
| --- | --- | --- | --- | --- | --- | --- | --- | --- | --- | --- | --- | --- |
| 1 | 1 | **前端开发计划** |  | 7d | 2017-11-27 08:00 | 2017-12-05 17:00 |  | -3.25d | 0d |  | 田军 | 56h |
| 2 | 1.1 | 前端开发框架搭建 |  | 2d | 2017-11-27 08:00 | 2017-11-28 17:00 |  | -3.25d | 0d | start no earlier than 2017-11-27 08:00 |  |  |
| 3 | 1.2 | **考试任务管理** |  | 1d | 2017-11-27 08:00 | 2017-11-27 17:00 |  |  |  |  |  |  |
| 4 | 1.2.1 | 列表页面 |  | 2h | 2017-11-29 08:00 | 2017-11-29 10:00 | 2 | -3.25d | 0d |  |  |  |
| 5 | 1.2.2 | 添加考试任务 |  | 6h | 2017-11-29 10:00 | 2017-11-29 17:00 | 4 | -3.25d | 0d |  |  |  |
| 6 | 1.2.3 | 修改考试任务 |  | 2h | 2017-11-30 08:00 | 2017-11-30 10:00 | 5 | -3.25d | 0d |  |  |  |
| 7 | 1.2.4 | 删除考试任务 |  | 2h | 2017-11-30 10:00 | 2017-11-30 12:00 | 6 | -3.25d | 0d |  |  |  |
| 8 | 1.2.5 | 查看考场数据 |  | 2h | 2017-11-30 13:00 | 2017-11-30 15:00 | 7 | -3.25d | 0d |  |  |  |
| 9 | 1.2.6 | 查看考务数据 |  | 4h | 2017-11-30 15:00 | 2017-12-01 10:00 | 8 | -3.25d | 0d |  |  |  |
| 10 | 1.3 | **结果汇总进度** |  | 0.5d | 2017-12-01 10:00 | 2017-12-01 15:00 |  | 0d |  |  |  |  |
| 11 | 1.3.1 | 列表页面 |  | 2h | 2017-12-01 10:00 | 2017-12-01 12:00 | 9 | 0d |  |  |  |  |
| 12 | 1.3.2 | 导入导出 |  | 2h | 2017-12-01 13:00 | 2017-12-01 15:00 | 11 | 0d |  |  |  |  |
| 13 | 1.4 | **查询统计** |  | 0.25d | 2017-12-01 15:00 | 2017-12-01 17:00 |  | 0d |  |  |  |  |
| 14 | 1.4.1 | 列表页面 |  | 2h | 2017-12-01 15:00 | 2017-12-01 17:00 | 12 | 0d |  |  |  |  |
| 15 | 1.5 | **系统管理** |  | 2d | 2017-12-04 08:00 | 2017-12-05 17:00 |  | 0d |  |  |  |  |
| 16 | 1.5.1 | 登录页面 |  | 4h | 2017-12-04 08:00 | 2017-12-04 12:00 | 14 | 0d |  |  |  |  |
| 17 | 1.5.2 | **用户管理** |  | 1d | 2017-12-04 13:00 | 2017-12-05 12:00 |  | 0d |  |  |  |  |
| 18 | 1.5.2.1 | 添加用户 |  | 3h | 2017-12-04 13:00 | 2017-12-04 16:00 | 16 | 0d |  |  |  |  |
| 19 | 1.5.2.2 | 修改用户 |  | 3h | 2017-12-04 16:00 | 2017-12-05 10:00 | 18 | 0d |  |  |  |  |
| 20 | 1.5.2.3 | 删除用户 |  | 2h | 2017-12-05 10:00 | 2017-12-05 12:00 | 19 | 0d |  |  |  |  |
| 21 | 1.5.3 | 用户修改密码 |  | 4h | 2017-12-05 13:00 | 2017-12-05 17:00 | 20 | 0d |  |  |  |  |
| 23 | 2 | 客户端联调 |  | 5d | 2017-12-06 08:00 | 2017-12-12 17:00 | 21 | 0d |  |  | 田军 | 40h |
| 25 | 3 | BUG以及完善 | manual | 2d | 2017-12-13 08:00 | 2017-12-14 17:00 | 23 |  |  |  | 田军 | 16h |
